# Project 2007-01 UFLS

Schedule from MS Project, 2006-11-01 to 2010-07-29, A marks actual dates.
Proposed Work Plan
NERC

## Calendars

- Standard: Mon-Fri 08:00-12:00, 13:00-17:00; Sat-Sun off. Exceptions (off unless hours are given): 2007-09-01 08:00-12:00, 13:00-17:00, 2008-06-15 08:00-12:00, 13:00-17:00, 2008-11-01 08:00-12:00, 13:00-17:00.

## Schedule

| ID | WBS | Task | Type | Duration | Start | Finish | Predecessors | Complete | Remaining | Baseline start | Baseline finish | Baseline duration | Total slack | Free slack | Constraint |
| --- | --- | --- | --- | --- | --- | --- | --- | --- | --- | --- | --- | --- | --- | --- | --- |
| 1 | 1 | **NERC Standard Development for Project 2007-01** |  | 828d | 2006-11-01 A | 2009-12-29 |  | 64% | 300.01d | 2007-01-02 | 2009-03-04 | 570d? | 152d |  |  |
| 2 | 1.1 | **SAR Development and Finalization** |  | 143d | 2006-11-01 A | 2007-05-18 A |  | 100% |  | 2007-01-02 | 2007-08-27 | 170d |  |  |  |
| 3 | 1.1.1 | Step 1a - RRSWG Drafts SAR |  | 15d | 2006-11-01 A | 2006-11-21 A |  | 100% |  | 2007-01-02 | 2007-02-12 | 30d |  |  | start no earlier than 2007-01-02 |
| 4 | 1.1.2 | Step 1b - Appoint SAR Drafting Team |  | 37d | 2006-11-21 A | 2007-01-10 A | 3FS-10d | 100% |  | 2007-01-30 | 2007-03-12 | 30d |  |  |  |
| 5 | 1.1.3 | Step 2a- SAR Posted for Comment |  | 73d | 2006-11-29 A | 2007-03-09 A | 4FS-20d | 100% |  | 2007-02-13 | 2007-05-07 | 60d |  |  | finish no earlier than 2007-03-09 |
| 6 | 1.1.4 | Step 2b - Address Comments |  | 60d | 2007-01-15 A | 2007-04-20 A | 5 | 100% |  | 2007-05-08 | 2007-07-30 | 60d |  |  |  |
| 7 | 1.1.5 | Step 3 - Authorization to Proceed by SC |  | 20d | 2007-04-23 A | 2007-05-18 A | 6 | 100% |  | 2007-07-31 | 2007-08-27 | 20d |  |  |  |
| 8 | 1.2 | **Standard Development and Implementation** |  | 767d | 2007-01-25 A | 2009-12-29 |  | 53% | 359.58d | 2007-07-31 | 2009-03-04 | 420d? | 152d |  |  |
| 9 | 1.2.1 | Step 4 - Appoint Standard Drafting Team |  | 30d | 2007-01-25 A | 2007-05-17 A | 7FS-10d | 100% |  | 2007-07-31 | 2007-09-07 | 30d |  |  |  |
| 10 | 1.2.2 | Step 5a - Draft Standard |  | 295.5d | 2007-05-17 A | 2008-07-01 A | 9 | 100% |  | 2007-09-10 | 2007-12-28 | 80d |  |  | finish no earlier than 2008-07-01 |
| 11 | 1.2.3 | Step 6a - Solicit Public Comment (Period 1) |  | 45d | 2008-07-02 A | 2008-09-02 A | 10 | 100% |  | 2007-12-31 | 2008-02-29 | 45d |  |  | finish no earlier than 2008-08-22 |
| 12 | 1.2.4 | Step 5 b - Answer Comments and Redraft |  | 114d | 2008-09-09 | 2009-02-12 | 11 |  |  | 2008-03-03 | 2008-05-23 | 60d | 0d |  | start no earlier than 2008-09-09 |
| 13 | 1.2.5 | Step 6b - Solicit Public Comment (Period 2) |  | 30d | 2009-02-13 | 2009-03-26 | 12 |  |  | 2008-05-26 | 2008-07-24 | 45d? | 167d | 15d |  |
| 14 | 1.2.6 | Step 6 c - Answer Comments and Redraft |  | 43d | 2009-04-17 | 2009-06-16 | 13 |  |  | 2008-03-03 | 2008-05-23 | 60d | 152d | 0d | finish no earlier than 2009-06-16 |
| 15 | 1.2.7 | Step 6b - Solicit Public Comment (Period 3) |  | 30d | 2009-06-17 | 2009-07-28 | 14 |  |  | 2008-05-26 | 2008-07-24 | 45d? | 152d | 0d |  |
| 16 | 1.2.8 | Step 6 c - Answer Comments and Redraft |  | 20d | 2009-07-29 | 2009-08-25 | 15 |  |  | 2008-03-03 | 2008-05-23 | 60d | 152d | 0d | finish no earlier than 2009-08-25 |
| 17 | 1.2.9 | Step 9 - Ballot/reballot |  | 60d | 2009-08-26 | 2009-11-17 | 16 |  |  | 2008-07-25 | 2008-10-16 | 60d | 152d | 0d |  |
| 18 | 1.2.10 | Step 10 - Submit to BOT Adoption |  | 30d | 2009-11-18 | 2009-12-29 | 17 |  |  | 2008-10-17 | 2008-11-26 | 30d | 152d | 0d |  |
| 19 | 1.2.11 | NERC BOT Adopt | milestone | 0d | 2009-12-29 | 2009-12-29 | 18 |  |  | 2008-11-26 | 2008-11-26 | 0d | 152d |  |  |
| 20 | 2 | **ERCOT Regional Standards Procedure** |  | 400d | 2009-01-16 | 2010-07-29 |  |  |  | 2008-04-28 | 2009-11-04 | 400d | 0d |  |  |
| 21 | 2.1 | ERCOT Regional Standard Development |  | 245d | 2009-01-16 | 2009-12-24 | 12FS-20d |  |  | 2008-04-28 | 2009-04-01 | 245d | 0d |  |  |
| 22 | 2.2 | NERC Approval of Regional Standard |  | 75d | 2009-11-20 | 2010-03-04 | 21FS-25d |  |  | 2009-02-26 | 2009-06-10 | 75d | 0d |  |  |
| 23 | 2.3 | Regulatory Approval of Regional Standard |  | 90d | 2010-01-29 | 2010-06-03 | 22FS-25d |  |  | 2009-05-07 | 2009-09-09 | 90d | 0d |  |  |
| 24 | 2.4 | Implementation of Standard |  | 40d | 2010-06-04 | 2010-07-29 | 23 |  |  | 2009-09-10 | 2009-11-04 | 40d | 0d |  |  |
| 25 | 2.5 | ERCOT Regional Standard Effective Date | milestone | 0d | 2010-07-29 | 2010-07-29 | 24 |  |  | 2009-11-04 | 2009-11-04 | 0d | 0d |  |  |

Notes:
- 5: The original schedule assumed one posting of the SAR for comment; however, based on commments received the SAR drafting team psoted the SAR for a second time. The additional posting adds two months of time to the overall schedule. To prevent total project slippage, the SAR drafting team will be requesting the Standards Committee to begin solicitation of volunteers for standard drafting team at the Feb 9 meeting of the Standards Committee. / Two sets of comments were received on the second posting of the SAR. Both sets of comments supported moving forward with the SAR.
- 9: The SC authorized solicitation of Standard Drafting Team members on their February 9, 2007 conference call. As of March 13, 2007 the nomination form had not been posted.

| ID | WBS | Task | Type | Duration | Start | Finish | Predecessors | Baseline start | Baseline finish | Baseline duration | Total slack |
| --- | --- | --- | --- | --- | --- | --- | --- | --- | --- | --- | --- |
| 26 | 3 | **FRCC Regional Standards Procedure** |  | 400d | 2009-01-16 | 2010-07-29 |  | 2008-04-28 | 2009-11-04 | 400d | 0d |
| 27 | 3.1 | FRCC Regional Standard Development |  | 245d | 2009-01-16 | 2009-12-24 | 12FS-20d | 2008-04-28 | 2009-04-01 | 245d | 0d |
| 28 | 3.2 | NERC Approval of Regional Standard |  | 75d | 2009-11-20 | 2010-03-04 | 27FS-25d | 2009-02-26 | 2009-06-10 | 75d | 0d |
| 29 | 3.3 | Regulatory Approval of Regional Standard |  | 90d | 2010-01-29 | 2010-06-03 | 28FS-25d | 2009-05-07 | 2009-09-09 | 90d | 0d |
| 30 | 3.4 | Implementation of Standard |  | 40d | 2010-06-04 | 2010-07-29 | 29 | 2009-09-10 | 2009-11-04 | 40d | 0d |
| 31 | 3.5 | FRCC Regional Standard Effective Date | milestone | 0d | 2010-07-29 | 2010-07-29 | 30 | 2009-11-04 | 2009-11-04 | 0d | 0d |
| 32 | 4 | **MRO Regional Standards Procedure** |  | 400d | 2009-01-16 | 2010-07-29 |  | 2008-04-28 | 2009-11-04 | 400d | 0d |
| 33 | 4.1 | MRO Regional Standard Development |  | 245d | 2009-01-16 | 2009-12-24 | 12FS-20d | 2008-04-28 | 2009-04-01 | 245d | 0d |
| 34 | 4.2 | NERC Approval of Regional Standard |  | 75d | 2009-11-20 | 2010-03-04 | 33FS-25d | 2009-02-26 | 2009-06-10 | 75d | 0d |
| 35 | 4.3 | Regulatory Approval of Regional Standard |  | 90d | 2010-01-29 | 2010-06-03 | 34FS-25d | 2009-05-07 | 2009-09-09 | 90d | 0d |
| 36 | 4.4 | Implementation of Standard |  | 40d | 2010-06-04 | 2010-07-29 | 35 | 2009-09-10 | 2009-11-04 | 40d | 0d |
| 37 | 4.5 | MRO Regional Standard Effective Date | milestone | 0d | 2010-07-29 | 2010-07-29 | 36 | 2009-11-04 | 2009-11-04 | 0d | 0d |
| 38 | 5 | **NPCC Regional Standards Procedure** |  | 400d | 2009-01-16 | 2010-07-29 |  | 2008-04-28 | 2009-11-04 | 400d | 0d |
| 39 | 5.1 | NPCC Regional Standard Development |  | 245d | 2009-01-16 | 2009-12-24 | 12FS-20d | 2008-04-28 | 2009-04-01 | 245d | 0d |
| 40 | 5.2 | NERC Approval of Regional Standard |  | 75d | 2009-11-20 | 2010-03-04 | 39FS-25d | 2009-02-26 | 2009-06-10 | 75d | 0d |
| 41 | 5.3 | Regulatory Approval of Regional Standard |  | 90d | 2010-01-29 | 2010-06-03 | 40FS-25d | 2009-05-07 | 2009-09-09 | 90d | 0d |
| 42 | 5.4 | Implementation of Standard |  | 40d | 2010-06-04 | 2010-07-29 | 41 | 2009-09-10 | 2009-11-04 | 40d | 0d |
| 43 | 5.5 | NPCC Regional Standard Effective Date | milestone | 0d | 2010-07-29 | 2010-07-29 | 42 | 2009-11-04 | 2009-11-04 | 0d | 0d |
| 44 | 6 | **RFC Regional Standards Procedure** |  | 400d | 2009-01-16 | 2010-07-29 |  | 2008-04-28 | 2009-11-04 | 400d | 0d |
| 45 | 6.1 | RFC Regional Standard Development |  | 245d | 2009-01-16 | 2009-12-24 | 12FS-20d | 2008-04-28 | 2009-04-01 | 245d | 0d |
| 46 | 6.2 | NERC Approval of Regional Standard |  | 75d | 2009-11-20 | 2010-03-04 | 45FS-25d | 2009-02-26 | 2009-06-10 | 75d | 0d |
| 47 | 6.3 | Regulatory Approval of Regional Standard |  | 90d | 2010-01-29 | 2010-06-03 | 46FS-25d | 2009-05-07 | 2009-09-09 | 90d | 0d |
| 48 | 6.4 | Implementation of Standard |  | 40d | 2010-06-04 | 2010-07-29 | 47 | 2009-09-10 | 2009-11-04 | 40d | 0d |
| 49 | 6.5 | RFC Regional Standard Effective Date | milestone | 0d | 2010-07-29 | 2010-07-29 | 48 | 2009-11-04 | 2009-11-04 | 0d | 0d |

| ID | WBS | Task | Type | Duration | Start | Finish | Predecessors | Baseline start | Baseline finish | Baseline duration | Total slack |
| --- | --- | --- | --- | --- | --- | --- | --- | --- | --- | --- | --- |
| 50 | 7 | **SERC Regional Standards Procedure** |  | 400d | 2009-01-16 | 2010-07-29 |  | 2008-04-28 | 2009-11-04 | 400d | 0d |
| 51 | 7.1 | SERC Regional Standard Development |  | 245d | 2009-01-16 | 2009-12-24 | 12FS-20d | 2008-04-28 | 2009-04-01 | 245d | 0d |
| 52 | 7.2 | NERC Approval of Regional Standard |  | 75d | 2009-11-20 | 2010-03-04 | 51FS-25d | 2009-02-26 | 2009-06-10 | 75d | 0d |
| 53 | 7.3 | Regulatory Approval of Regional Standard |  | 90d | 2010-01-29 | 2010-06-03 | 52FS-25d | 2009-05-07 | 2009-09-09 | 90d | 0d |
| 54 | 7.4 | Implementation of Standard |  | 40d | 2010-06-04 | 2010-07-29 | 53 | 2009-09-10 | 2009-11-04 | 40d | 0d |
| 55 | 7.5 | SERC Regional Standard Effective Date | milestone | 0d | 2010-07-29 | 2010-07-29 | 54 | 2009-11-04 | 2009-11-04 | 0d | 0d |
| 56 | 8 | **SPP Regional Standards Procedure** |  | 400d | 2009-01-16 | 2010-07-29 |  | 2008-04-28 | 2009-11-04 | 400d | 0d |
| 57 | 8.1 | SPP Regional Standard Development |  | 245d | 2009-01-16 | 2009-12-24 | 12FS-20d | 2008-04-28 | 2009-04-01 | 245d | 0d |
| 58 | 8.2 | NERC Approval of Regional Standard |  | 75d | 2009-11-20 | 2010-03-04 | 57FS-25d | 2009-02-26 | 2009-06-10 | 75d | 0d |
| 59 | 8.3 | Regulatory Approval of Regional Standard |  | 90d | 2010-01-29 | 2010-06-03 | 58FS-25d | 2009-05-07 | 2009-09-09 | 90d | 0d |
| 60 | 8.4 | Implementation of Standard |  | 40d | 2010-06-04 | 2010-07-29 | 59 | 2009-09-10 | 2009-11-04 | 40d | 0d |
| 61 | 8.5 | SPP Regional Standard Effective Date | milestone | 0d | 2010-07-29 | 2010-07-29 | 60 | 2009-11-04 | 2009-11-04 | 0d | 0d |
| 62 | 9 | **WECC Regional Standards Procedure** |  | 400d | 2009-01-16 | 2010-07-29 |  | 2008-04-28 | 2009-11-04 | 400d | 0d |
| 63 | 9.1 | WECC Regional Standard Development |  | 245d | 2009-01-16 | 2009-12-24 | 12FS-20d | 2008-04-28 | 2009-04-01 | 245d | 0d |
| 64 | 9.2 | NERC Approval of Regional Standard |  | 75d | 2009-11-20 | 2010-03-04 | 63FS-25d | 2009-02-26 | 2009-06-10 | 75d | 0d |
| 65 | 9.3 | Regulatory Approval of Regional Standard |  | 90d | 2010-01-29 | 2010-06-03 | 64FS-25d | 2009-05-07 | 2009-09-09 | 90d | 0d |
| 66 | 9.4 | Implementation of Standard |  | 40d | 2010-06-04 | 2010-07-29 | 65 | 2009-09-10 | 2009-11-04 | 40d | 0d |
| 67 | 9.5 | WECC Regional Standard Effective Date | milestone | 0d | 2010-07-29 | 2010-07-29 | 66 | 2009-11-04 | 2009-11-04 | 0d | 0d |
